# SUBPROYECTO A2 - TRAMO 1

Schedule from Primavera P6, 2023-11-15 to 2025-03-01, data date 2023-11-15.

## Calendars

- Huara III: Mon-Sat 08:00-16:00; Sun off.

## Resources

| Resource | Group |
| --- | --- |
| HH | labor |

## Schedule

| ID | WBS | Activity | Type | Duration | Start | Finish | Predecessors | Total float | Free float | Resources |
| --- | --- | --- | --- | --- | --- | --- | --- | --- | --- | --- |
|  | 0 | **HITOS** |  |  | 2023-11-15 | 2025-03-01 |  |  |  |  |
| A1000 |  | KICK OFF MEETING | milestone | 0d | 2023-11-15 | 2023-11-15 |  | 0d |  |  |
| A1010 |  | INICIO DE PLAZO CONTRACTUAL - ACCESO AL SITIO | milestone | 0d | 2023-12-01 | 2023-12-01 | A1000 SS+14d | 0d |  |  |
| A1015 |  | INICIO DE EXCAVACIÓN | milestone | 0d | 2023-12-06 | 2023-12-06 | A1010 SS+4d | 259d | 0d |  |
| A1016 |  | INICIO DE RELLENO DE DIQUE | milestone | 0d | 2023-12-28 | 2023-12-28 | A1015 SS+19d | 369d |  |  |
| A1020 |  | FIN DEL SERVICIO | milestone | 0d | 2025-03-01 | 2025-03-01 | A1200, A1780 FF, A1070, A1050, A4710 FF, A1730 FF, A7170 FF, A7190 FF, A7220 FF, A7230 FF, A7200 FF, A7210 FF, A7240 FF, A7250 FF, A7260 FF, A7270 FF, A4000 FF, A4650 FF, A1150 SF, A1870 FF, A7740 FF, A7630 FF, A8160 FF, A8490 FF, A1080 | 0d |  |  |
|  | 1 | **TRABAJOS INICIALES** |  |  | 2023-12-01 | 2025-03-01 |  |  |  |  |
|  | 1 | **OBRAS PRELIMINARES** |  |  | 2023-12-01 | 2024-05-28 |  |  |  |  |
| A1030 |  | CARTEL DE IDENTIFICACIÓN OBRA 4.80 x 3.60 m. |  | 2d | 2023-12-01 | 2023-12-02 | A1010 SS | 0d |  | HH [16 h] |
| A1040 |  | INSTALACIONES PROVISIONALES PARA LA OBRA |  | 4d | 2023-12-01 | 2023-12-05 | A1010 SS, A1030 SS | 0d |  | HH [32 h] |
| A1050 |  | MANTENIMIENTO DE TRÁNSITO Y SEGURIDAD VIAL |  | 154d | 2023-12-01 | 2024-05-28 | A1010 SS | 238d | 3d | HH [1232 h] |
|  | 2 | **TRABAJOS PRELIMINARES** |  |  | 2023-12-01 | 2025-03-01 |  |  |  |  |
| A1060 |  | MOVILIZACION DE EQUIPOS |  | 4d | 2023-12-01 | 2023-12-05 | A1010 | 0d |  | HH [32 h] |
| A1070 |  | TOPOGRAFÍA Y GEOREFERENCIACIÓN |  | 387d | 2023-12-06 | 2025-02-28 | A1040 | 1d |  | HH [3096 h] |
| A1080 |  | DESMOVILIZACION DE EQUIPOS |  | 7d | 2025-02-22 | 2025-03-01 | A1770 | 0d |  | HH [56 h] |
|  | 3 | **MEJORAMIENTO DE VÍAS EXISTENTES** |  |  | 2023-12-06 | 2025-02-03 |  |  |  |  |
|  | 1 | **MOVIMIENTO DE TIERRAS** |  |  | 2023-12-06 | 2024-05-03 |  |  |  |  |
| A1090 |  | ROCE Y LIMPIEZA DE MALEZA |  | 30d | 2023-12-06 | 2024-01-09 | A1015, A1060 | 259d | 0d | HH [240 h] |
| A1100 |  | REHABILITACIÓN DE VÍAS EXISTENTES |  | 129d | 2023-12-06 | 2024-05-03 | A1090 SS, A1050 SS+1d | 259d | 0d | HH [1032 h] |
| A4650 |  | CONFORMACIÓN DE TERRAPLENES EN CAMINO |  | 30d | 2023-12-08 | 2024-01-11 | A1100 SS+2d | 356d |  | HH [240 h] |
|  | 2 | **REPOSICIÓN DE ESTRUCTURAS** |  |  | 2023-12-07 | 2025-01-22 |  |  |  |  |
| A1150 |  | DEMOLICIÓN DE ESTRUCTURAS EXISTENTES |  | 2d | 2023-12-07 | 2023-12-08 | A7430 SS | 385d | 387d | HH [16 h] |
| A1160 |  | REPOSICIÓN DE PASE DE AGUA TUBO HDPE Ø=18" |  | 2d | 2025-01-17 | 2025-01-18 | A8440 SS | 23d | 0d | HH [16 h] |
| A1170 |  | REPOSICIÓN DE PASE DE AGUA TUBO HDPE Ø=36" |  | 3d | 2025-01-17 | 2025-01-20 | A1160 SS | 23d | 0d | HH [24 h] |
| A1180 |  | SUMINISTRO Y MONTAJE DE PANELES DE C°A° 1.9mx1.0mx0.20m EN PASE DE AGUA |  | 2d | 2025-01-20 | 2025-01-21 | A1170 SS+2d | 23d | 0d | HH [16 h] |
| A1190 |  | SUMINISTRO Y MONTAJE DE PANELES DE C°A° 1.6mx1.0mx0.20m EN PASE DE AGUA |  | 2d | 2025-01-20 | 2025-01-21 | A1180 SS | 24d | 1d | HH [16 h] |
| A4660 |  | SUMINISTRO Y MONTAJE DE PANELES DE C°A° 1.8mx1.0mx0.20m EN PASE DE AGUA |  | 2d | 2025-01-21 | 2025-01-22 | A1180 SS+1d | 23d | 0d | HH [16 h] |

| ID | WBS | Activity | Type | Duration | Start | Finish | Predecessors | Total float | Free float | Resources | Filtro |
| --- | --- | --- | --- | --- | --- | --- | --- | --- | --- | --- | --- |
|  | 4 | **CABEZAL DE ENTRADA Y SALIDA** |  |  | 2025-01-23 | 2025-02-03 |  |  |  |  |  |
| A1210 |  | ENCOFRADO Y DESENCOFRADO NORMAL |  | 6d | 2025-01-23 | 2025-01-29 | A1190, A4660 | 23d | 0d | HH [48 h] |  |
| A1200 |  | CONCRETO 175 Kg/Cm2 |  | 4d | 2025-01-30 | 2025-02-03 | A1210 | 23d |  | HH [32 h] |  |
|  | 4 | **DESCOLMATACIÓN DE CAUCE Y OBRAS AUXILIARES** |  |  | 2023-12-05 | 2025-03-01 |  |  |  |  |  |
|  | 1 | **DESBROCE Y DESCOLMATACIÓN** |  |  | 2023-12-05 | 2025-03-01 |  |  |  |  |  |
| A1220 |  | DESBROCE Y LIMPIEZA EN ZONA NO BOSCOSA |  | 300d | 2023-12-05 | 2024-11-18 | A1060 SS+3d | 0d |  | HH [2400 h] | Excavación |
| A1230 |  | DESCOLMATACIÓN DE CAUCE NATURAL DEL RÍO LACRAMARCA |  | 279d | 2023-12-07 | 2024-10-26 | A1220 SS+2d | 0d |  | HH [2232 h] | Excavación |
| A1880 |  | CONFORMACIÓN DE DESVIO EN CAUCE DE RÍO |  | 384d | 2023-12-11 | 2025-03-01 | A1230 SS+3d | 0d |  | HH [3072 h] | Excavación |
| A1870 |  | RELLENO NO ESTRUCTURAL CON MATERIAL PROPIO |  | 382d | 2023-12-13 | 2025-03-01 | A1880 SS+2d | 0d |  | HH [3056 h] | Excavación |
|  | 7 | **CRUCE VEHICULAR** |  |  | 2025-01-10 | 2025-02-12 |  |  |  |  |  |
|  | 1 | **MEJORAMIENTO DE CRUCE VEHICULAR** |  |  | 2025-01-10 | 2025-02-12 |  |  |  |  |  |
| A4670 |  | VACIADO DE CONCRETO f´c=280 Kg/cm2 |  | 3d | 2025-01-10 | 2025-01-13 | A8390 SS | 15d | 0d | HH [24 h] |  |
| A4680 |  | VACIADO DE CONCRETO CICLÓPEO f'c=170 kg/cm2 |  | 3d | 2025-01-14 | 2025-01-16 | A4670 | 15d | 0d | HH [24 h] |  |
| A4690 |  | ACERO DE REFUERZO fy=4200 kg/cm2 |  | 21d | 2025-01-17 | 2025-02-10 | A4680 | 15d | 0d | HH [168 h] |  |
| A4700 |  | ENCOFRADO Y DESENCOFRADO NORMAL |  | 15d | 2025-01-24 | 2025-02-10 | A4690 SS+6d | 15d | 0d | HH [120 h] |  |
| A4710 |  | MONTAJE DE LOSA PREFABRICADA |  | 11d | 2025-01-31 | 2025-02-12 | A4700 SS+6d | 15d |  | HH [88 h] |  |
|  | 6 | **RAMPAS** |  |  | 2024-02-29 | 2025-02-28 |  |  |  |  |  |
|  | 1 | **CONSTRUCCION DE RAMPAS** |  |  | 2024-02-29 | 2025-02-28 |  |  |  |  |  |
| A1710 |  | EXCAVACIÓN EN TERRENO NATURAL CON EQUIPO |  | 314d | 2024-02-29 | 2025-02-28 | A7470 FS+2d | 1d | 0d | HH [2512 h] | Excavación |
| A1720 |  | CONFORMACIÓN DE CUERPO DE RAMPA CON MATERIAL PROPIO |  | 313d | 2024-03-01 | 2025-02-28 | A1710 SS+1d | 1d | 0d | HH [2504 h] | Relleno |
| A1730 |  | CONFORMACIÓN DE CORONACIÓN DE RAMPA |  | 312d | 2024-03-02 | 2025-02-28 | A1720 SS+1d | 1d |  | HH [2496 h] | Relleno |
|  | 16 | **DIQUES DE TIERRA COMPACTADA CON ENROCADO** |  |  | 2023-12-06 | 2025-03-01 |  |  |  |  |  |
|  | 16 | **DIQUE A2-I-03** |  |  | 2023-12-06 | 2025-03-01 |  |  |  |  |  |
|  | 2 | **DIQUE DE TIERRA COMPACTADA A2-I-03 SIN AFECTACION** |  |  | 2023-12-06 | 2024-02-28 |  |  |  |  |  |
| A7420 |  | ENTREGA DE TERRENO | milestone | 0d | 2023-12-06 | 2023-12-06 | A1040 | 0d |  |  |  |
| A7430 |  | EXCAVACIÓN EN TERRENO NATURAL CON EQUIPO |  | 52d | 2023-12-07 | 2024-02-05 | A7420 SS+1d | 0d |  | HH [416 h] | Excavación |
| A7440 |  | EXCAVACIÓN DE UÑA CON EQUIPO |  | 52d | 2023-12-08 | 2024-02-06 | A7430 SS+1d | 0d |  | HH [416 h] | Excavación |
| A7450 |  | PERFILADO EN ZONA DE CORTE TALUD DE DIQUE |  | 52d | 2023-12-08 | 2024-02-06 | A7430 SS+1d | 0d |  | HH [416 h] |  |
| A7460 |  | PREPARACIÓN DE FUNDACIÓN DE CUERPO DE DIQUE |  | 52d | 2023-12-09 | 2024-02-07 | A7430 SS+1d, A7450 SS+1d, A7440 SS+1d | 0d |  | HH [416 h] |  |
| A7470 |  | CONFORMACIÓN DE CUERPO DE DIQUE CON MATERIAL PROPIO |  | 52d | 2023-12-28 | 2024-02-26 | A7460 SS+16d | 0d |  | HH [416 h] | Relleno |
| A7480 |  | GEOTEXTIL NO TEJIDO 400 G/M2, INC. COLOCACIÓN |  | 52d | 2023-12-28 | 2024-02-26 | A7470 SS | 0d |  | HH [416 h] |  |
| A7490 |  | PERFILADO Y COMPACTACIÓN EN ZONA DE CORTE EN CORONA |  | 52d | 2023-12-28 | 2024-02-26 | A7480 SS | 0d |  | HH [416 h] |  |
| A7500 |  | CONFORMACIÓN DE MATERIAL GRANULAR EN CORONA DE DIQUE |  | 52d | 2023-12-29 | 2024-02-27 | A7490 SS+1d | 0d |  | HH [416 h] | Relleno |
| A7510 |  | COLOCACION Y ACOMODO DE ROCA EN UÑA DE DIQUE |  | 52d | 2023-12-29 | 2024-02-27 | A7500 SS | 0d |  | HH [416 h] | Roca |
| A7520 |  | COLOCACION Y ACOMODO DE ROCA EN TALUD DE DIQUE |  | 53d | 2023-12-29 | 2024-02-28 | A7510 SS | 28d |  | HH [424 h] | Roca |

| ID | WBS | Activity | Type | Duration | Start | Finish | Predecessors | Total float | Free float | Resources | Filtro |
| --- | --- | --- | --- | --- | --- | --- | --- | --- | --- | --- | --- |
|  | 12 | **DIQUE DE TIERRA COMPACTADA A2-I-03 CON AFECTACION** |  |  | 2024-10-30 | 2024-11-29 |  |  |  |  |  |
| A7540 |  | ENTREGA DE TERRENO | milestone | 0d | 2024-10-30 | 2024-10-30 | A8630 | 79d | 0d |  |  |
| A7530 |  | EXCAVACIÓN EN TERRENO NATURAL CON EQUIPO |  | 15d | 2024-10-31 | 2024-11-16 | A7540 SS+1d | 79d | 0d | HH [120 h] | Excavación |
| A7550 |  | EXCAVACIÓN DE UÑA CON EQUIPO |  | 15d | 2024-11-01 | 2024-11-18 | A7530 SS+1d | 80d | 1d | HH [120 h] | Excavación |
| A7560 |  | PERFILADO EN ZONA DE CORTE TALUD DE DIQUE |  | 15d | 2024-11-02 | 2024-11-19 | A7530 SS+2d | 79d | 0d | HH [120 h] |  |
| A7570 |  | PREPARACIÓN DE FUNDACIÓN DE CUERPO DE DIQUE |  | 15d | 2024-11-04 | 2024-11-20 | A7530 SS+1d, A7560 SS+1d, A7550 SS+1d | 79d | 0d | HH [120 h] |  |
| A7580 |  | CONFORMACIÓN DE CUERPO DE DIQUE CON MATERIAL PROPIO |  | 15d | 2024-11-05 | 2024-11-21 | A7570 SS+1d | 79d | 0d | HH [120 h] | Relleno |
| A7590 |  | GEOTEXTIL NO TEJIDO 400 G/M2, INC. COLOCACIÓN |  | 15d | 2024-11-06 | 2024-11-22 | A7580 SS+1d | 79d | 0d | HH [120 h] |  |
| A7600 |  | PERFILADO Y COMPACTACIÓN EN ZONA DE CORTE EN CORONA |  | 15d | 2024-11-07 | 2024-11-23 | A7590 SS+1d | 79d | 0d | HH [120 h] |  |
| A7610 |  | CONFORMACIÓN DE MATERIAL GRANULAR EN CORONA DE DIQUE |  | 15d | 2024-11-08 | 2024-11-25 | A7600 SS+1d | 79d | 0d | HH [120 h] | Relleno |
| A7620 |  | COLOCACION Y ACOMODO DE ROCA EN UÑA DE DIQUE |  | 15d | 2024-11-11 | 2024-11-27 | A7610 SS+2d | 79d | 0d | HH [120 h] | Roca |
| A7630 |  | COLOCACION Y ACOMODO DE ROCA EN TALUD DE DIQUE |  | 15d | 2024-11-13 | 2024-11-29 | A7620 SS+2d | 79d |  | HH [120 h] | Roca |
|  | 14 | **DIQUE DE TIERRA COMPACTADA A2-I-03 POR LIBERAR** |  |  | 2025-01-10 | 2025-03-01 |  |  |  |  |  |
| A7640 |  | ENTREGA DE TERRENO | milestone | 0d | 2025-01-10 | 2025-01-10 | A9300 | 0d |  |  |  |
| A7650 |  | EXCAVACIÓN EN TERRENO NATURAL CON EQUIPO |  | 33d | 2025-01-11 | 2025-02-18 | A7640 SS+1d | 0d |  | HH [264 h] | Excavación |
| A7660 |  | EXCAVACIÓN DE UÑA CON EQUIPO |  | 33d | 2025-01-14 | 2025-02-20 | A7650 SS+2d | 0d |  | HH [264 h] | Excavación |
| A7670 |  | PERFILADO EN ZONA DE CORTE TALUD DE DIQUE |  | 33d | 2025-01-14 | 2025-02-20 | A7650 SS+2d | 0d |  | HH [264 h] |  |
| A7680 |  | PREPARACIÓN DE FUNDACIÓN DE CUERPO DE DIQUE |  | 33d | 2025-01-15 | 2025-02-21 | A7650 SS+1d, A7670 SS+1d, A7660 SS+1d | 0d |  | HH [264 h] |  |
| A7690 |  | CONFORMACIÓN DE CUERPO DE DIQUE CON MATERIAL PROPIO |  | 33d | 2025-01-16 | 2025-02-22 | A7680 SS+1d | 0d |  | HH [264 h] | Relleno |
| A7700 |  | GEOTEXTIL NO TEJIDO 400 G/M2, INC. COLOCACIÓN |  | 33d | 2025-01-18 | 2025-02-25 | A7690 SS+2d | 0d |  | HH [264 h] |  |
| A7710 |  | PERFILADO Y COMPACTACIÓN EN ZONA DE CORTE EN CORONA |  | 33d | 2025-01-18 | 2025-02-25 | A7700 SS | 0d |  | HH [264 h] |  |
| A7720 |  | CONFORMACIÓN DE MATERIAL GRANULAR EN CORONA DE DIQUE |  | 33d | 2025-01-20 | 2025-02-26 | A7710 SS+1d | 0d |  | HH [264 h] | Relleno |
| A7730 |  | COLOCACION Y ACOMODO DE ROCA EN UÑA DE DIQUE |  | 33d | 2025-01-22 | 2025-02-28 | A7720 SS+2d | 0d |  | HH [264 h] | Roca |
| A7740 |  | COLOCACION Y ACOMODO DE ROCA EN TALUD DE DIQUE |  | 33d | 2025-01-23 | 2025-03-01 | A7730 SS+1d | 0d |  | HH [264 h] | Roca |

| ID | WBS | Activity | Type | Duration | Start | Finish | Predecessors | Total float | Free float | Resources | Filtro |
| --- | --- | --- | --- | --- | --- | --- | --- | --- | --- | --- | --- |
|  | 8 | **DIQUE A2-I-2** |  |  | 2024-01-31 | 2024-10-28 |  |  |  |  |  |
|  | 6 | **DIQUE DE TIERRA COMPACTADA A2-I-02 SIN AFECTACION** |  |  | 2024-01-31 | 2024-05-04 |  |  |  |  |  |
| A7750 |  | ENTREGA DE TERRENO | milestone | 0d | 2024-01-31 | 2024-01-31 | A8270, A7520 SS | 0d |  |  |  |
| A7760 |  | EXCAVACIÓN EN TERRENO NATURAL CON EQUIPO |  | 72d | 2024-02-01 | 2024-04-24 | A7750 SS+1d | 0d |  | HH [576 h] | Excavación |
| A7770 |  | EXCAVACIÓN DE UÑA CON EQUIPO |  | 72d | 2024-02-02 | 2024-04-25 | A7760 SS+1d | 0d |  | HH [576 h] | Excavación |
| A7780 |  | PERFILADO EN ZONA DE CORTE TALUD DE DIQUE |  | 72d | 2024-02-02 | 2024-04-25 | A7760 SS+1d | 1d | 0d | HH [576 h] |  |
| A7790 |  | PREPARACIÓN DE FUNDACIÓN DE CUERPO DE DIQUE |  | 72d | 2024-02-03 | 2024-04-26 | A7760 SS+1d, A7780 SS, A7770 SS+1d | 0d |  | HH [576 h] |  |
| A7800 |  | PEDRAPLEN e=60 cm |  | 72d | 2024-02-03 | 2024-04-26 | A7780 FF+1d | 1d | 0d | HH [576 h] | Roca |
| A7810 |  | PEDRAPLEN e=30 cm |  | 72d | 2024-02-03 | 2024-04-26 | A7800 FF | 1d |  | HH [576 h] | Roca |
| A7820 |  | CONFORMACIÓN DE CUERPO DE DIQUE CON MATERIAL PROPIO |  | 72d | 2024-02-05 | 2024-04-27 | A7790 SS+1d, A7810 SS | 0d |  | HH [576 h] | Relleno |
| A7830 |  | CONFORMACIÓN DE RELLENO NO ESTRUCTURAL CON MATERIAL PROPIO |  | 72d | 2024-02-06 | 2024-04-29 | A7820 SS+1d | 0d |  | HH [576 h] | Relleno |
| A7840 |  | GEOTEXTIL NO TEJIDO 400 G/M2, INC. COLOCACIÓN |  | 72d | 2024-02-07 | 2024-04-30 | A7820 SS, A7830 SS+1d | 0d |  | HH [576 h] |  |
| A7850 |  | PERFILADO Y COMPACTACIÓN EN ZONA DE CORTE EN CORONA |  | 72d | 2024-02-08 | 2024-05-01 | A7840 SS+1d | 0d |  | HH [576 h] |  |
| A7860 |  | CONFORMACIÓN DE MATERIAL GRANULAR EN CORONA DE DIQUE |  | 72d | 2024-02-09 | 2024-05-02 | A7850 SS+1d | 0d |  | HH [576 h] | Relleno |
| A7870 |  | COLOCACION Y ACOMODO DE ROCA EN UÑA DE DIQUE |  | 72d | 2024-02-10 | 2024-05-03 | A7860 SS+1d | 0d |  | HH [576 h] | Roca |
| A7880 |  | COLOCACION Y ACOMODO DE ROCA EN TALUD DE DIQUE |  | 72d | 2024-02-12 | 2024-05-04 | A7870 SS+1d | 0d |  | HH [576 h] | Roca |
|  | 7 | **DIQUE DE TIERRA COMPACTADA A2-I-02 CON AFECTACION** |  |  | 2024-08-31 | 2024-10-12 |  |  |  |  |  |
| A7890 |  | ENTREGA DE TERRENO | milestone | 0d | 2024-08-31 | 2024-08-31 | A9020 | 107d | 0d |  |  |
| A7900 |  | EXCAVACIÓN EN TERRENO NATURAL CON EQUIPO |  | 25d | 2024-09-02 | 2024-09-30 | A7890 SS+1d | 107d | 0d | HH [200 h] | Excavación |
| A7910 |  | EXCAVACIÓN DE UÑA CON EQUIPO |  | 25d | 2024-09-03 | 2024-10-01 | A7900 SS+1d | 108d | 0d | HH [200 h] | Excavación |
| A7920 |  | PERFILADO EN ZONA DE CORTE TALUD DE DIQUE |  | 25d | 2024-09-04 | 2024-10-02 | A7900 SS+2d | 107d | 0d | HH [200 h] |  |
| A7930 |  | PREPARACIÓN DE FUNDACIÓN DE CUERPO DE DIQUE |  | 25d | 2024-09-04 | 2024-10-02 | A7900 SS+1d, A7920 SS, A7910 SS+1d | 108d | 1d | HH [200 h] |  |
| A7940 |  | PEDRAPLEN e=60 cm |  | 25d | 2024-09-05 | 2024-10-03 | A7920 FF+1d | 107d | 0d | HH [200 h] | Roca |
| A7950 |  | CONFORMACIÓN DE CUERPO DE DIQUE CON MATERIAL PROPIO |  | 25d | 2024-09-06 | 2024-10-04 | A7930 SS+1d, A7960 SS | 107d | 0d | HH [200 h] | Relleno |
| A7960 |  | PEDRAPLEN e=30 cm |  | 25d | 2024-09-06 | 2024-10-04 | A7940 FF+1d | 107d | 0d | HH [200 h] | Roca |
| A7970 |  | CONFORMACIÓN DE RELLENO NO ESTRUCTURAL CON MATERIAL PROPIO |  | 25d | 2024-09-07 | 2024-10-05 | A7950 SS+1d | 107d | 0d | HH [200 h] | Relleno |
| A7980 |  | GEOTEXTIL NO TEJIDO 400 G/M2, INC. COLOCACIÓN |  | 25d | 2024-09-09 | 2024-10-07 | A7950 SS, A7970 SS+1d | 107d | 0d | HH [200 h] |  |
| A7990 |  | PERFILADO Y COMPACTACIÓN EN ZONA DE CORTE EN CORONA |  | 25d | 2024-09-11 | 2024-10-09 | A7980 SS+2d | 107d | 0d | HH [200 h] |  |
| A8000 |  | CONFORMACIÓN DE MATERIAL GRANULAR EN CORONA DE DIQUE |  | 25d | 2024-09-12 | 2024-10-10 | A7990 SS+1d | 107d | 0d | HH [200 h] | Relleno |
| A8010 |  | COLOCACION Y ACOMODO DE ROCA EN UÑA DE DIQUE |  | 25d | 2024-09-13 | 2024-10-11 | A8000 SS+1d | 107d | 0d | HH [200 h] | Roca |
| A8020 |  | COLOCACION Y ACOMODO DE ROCA EN TALUD DE DIQUE |  | 25d | 2024-09-14 | 2024-10-12 | A8010 SS+1d | 107d | 0d | HH [200 h] | Roca |

| ID | WBS | Activity | Type | Duration | Start | Finish | Predecessors | Total float | Free float | Resources | Filtro |
| --- | --- | --- | --- | --- | --- | --- | --- | --- | --- | --- | --- |
|  | 11 | **DIQUE DE TIERRA COMPACTADA A2-I-02 POR LIBERAR** |  |  | 2024-10-14 | 2024-10-28 |  |  |  |  |  |
| A8030 |  | ENTREGA DE TERRENO | milestone | 0d | 2024-10-14 | 2024-10-14 | A8020 | 107d | 0d |  |  |
| A8040 |  | EXCAVACIÓN EN TERRENO NATURAL CON EQUIPO |  | 5d | 2024-10-15 | 2024-10-19 | A8030 SS+1d | 107d | 0d | HH [40 h] | Excavación |
| A8050 |  | EXCAVACIÓN DE UÑA CON EQUIPO |  | 5d | 2024-10-16 | 2024-10-21 | A8040 SS+1d | 107d | 0d | HH [40 h] | Excavación |
| A8060 |  | PERFILADO EN ZONA DE CORTE TALUD DE DIQUE |  | 5d | 2024-10-16 | 2024-10-21 | A8040 SS+1d | 108d | 0d | HH [40 h] |  |
| A8070 |  | PREPARACIÓN DE FUNDACIÓN DE CUERPO DE DIQUE |  | 5d | 2024-10-17 | 2024-10-22 | A8040 SS+1d, A8060 SS, A8050 SS+1d | 107d | 0d | HH [40 h] |  |
| A8080 |  | PEDRAPLEN e=60 cm |  | 5d | 2024-10-17 | 2024-10-22 | A8060 FF+1d | 108d | 0d | HH [40 h] | Roca |
| A8090 |  | PEDRAPLEN e=30 cm |  | 5d | 2024-10-17 | 2024-10-22 | A8080 FF | 108d | 1d | HH [40 h] | Roca |
| A8100 |  | CONFORMACIÓN DE CUERPO DE DIQUE CON MATERIAL PROPIO |  | 5d | 2024-10-18 | 2024-10-23 | A8070 SS+1d, A8090 SS | 107d | 0d | HH [40 h] | Relleno |
| A8110 |  | CONFORMACIÓN DE RELLENO NO ESTRUCTURAL CON MATERIAL PROPIO |  | 5d | 2024-10-19 | 2024-10-24 | A8100 SS+1d | 107d | 0d | HH [40 h] | Relleno |
| A8120 |  | GEOTEXTIL NO TEJIDO 400 G/M2, INC. COLOCACIÓN |  | 5d | 2024-10-21 | 2024-10-25 | A8100 SS, A8110 SS+1d | 107d | 0d | HH [40 h] |  |
| A8130 |  | PERFILADO Y COMPACTACIÓN EN ZONA DE CORTE EN CORONA |  | 5d | 2024-10-22 | 2024-10-26 | A8120 SS+1d | 107d | 0d | HH [40 h] |  |
| A8140 |  | CONFORMACIÓN DE MATERIAL GRANULAR EN CORONA DE DIQUE |  | 4d | 2024-10-23 | 2024-10-26 | A8130 SS+1d | 107d | 0d | HH [32 h] | Relleno |
| A8150 |  | COLOCACION Y ACOMODO DE ROCA EN UÑA DE DIQUE |  | 4d | 2024-10-24 | 2024-10-28 | A8140 SS+1d | 107d | 0d | HH [32 h] | Roca |
| A8160 |  | COLOCACION Y ACOMODO DE ROCA EN TALUD DE DIQUE |  | 4d | 2024-10-24 | 2024-10-28 | A8150 SS | 107d |  | HH [32 h] | Roca |
|  | 10 | **DIQUE A2-I-1** |  |  | 2024-08-31 | 2025-02-07 |  |  |  |  |  |
|  | 9 | **DIQUE DE TIERRA COMPACTADA A2-I-01 SIN AFECTACION** |  |  | 2024-08-31 | 2024-10-29 |  |  |  |  |  |
| A8500 |  | ENTREGA DE TERRENO | milestone | 0d | 2024-08-31 | 2024-08-31 | A9020 | 79d | 0d |  |  |
| A8510 |  | EXCAVACIÓN EN TERRENO NATURAL CON EQUIPO |  | 41d | 2024-09-02 | 2024-10-18 | A8500 SS+1d | 79d | 0d | HH [328 h] | Excavación |
| A8520 |  | EXCAVACIÓN DE UÑA CON EQUIPO |  | 41d | 2024-09-03 | 2024-10-19 | A8510 SS+1d | 79d | 0d | HH [328 h] | Excavación |
| A8530 |  | PERFILADO EN ZONA DE CORTE TALUD DE DIQUE |  | 41d | 2024-09-03 | 2024-10-19 | A8510 SS+1d | 80d | 0d | HH [328 h] |  |
| A8540 |  | PREPARACIÓN DE FUNDACIÓN DE CUERPO DE DIQUE |  | 41d | 2024-09-04 | 2024-10-21 | A8510 SS+1d, A8530 SS, A8520 SS+1d | 79d | 0d | HH [328 h] |  |
| A8550 |  | PEDRAPLEN e=60 cm |  | 41d | 2024-09-04 | 2024-10-21 | A8530 FF+1d | 80d | 0d | HH [328 h] | Roca |
| A8560 |  | PEDRAPLEN e=30 cm |  | 41d | 2024-09-04 | 2024-10-21 | A8550 FF | 80d | 1d | HH [328 h] | Roca |
| A8570 |  | CONFORMACIÓN DE CUERPO DE DIQUE CON MATERIAL PROPIO |  | 41d | 2024-09-05 | 2024-10-22 | A8540 SS+1d, A8560 SS | 79d | 0d | HH [328 h] | Relleno |
| A8580 |  | CONFORMACIÓN DE RELLENO NO ESTRUCTURAL CON MATERIAL PROPIO |  | 41d | 2024-09-06 | 2024-10-23 | A8570 SS+1d | 79d | 0d | HH [328 h] | Relleno |
| A8590 |  | GEOTEXTIL NO TEJIDO 400 G/M2, INC. COLOCACIÓN |  | 41d | 2024-09-07 | 2024-10-24 | A8570 SS, A8580 SS+1d | 79d | 0d | HH [328 h] |  |
| A8600 |  | PERFILADO Y COMPACTACIÓN EN ZONA DE CORTE EN CORONA |  | 41d | 2024-09-09 | 2024-10-25 | A8590 SS+1d | 79d | 0d | HH [328 h] |  |
| A8610 |  | CONFORMACIÓN DE MATERIAL GRANULAR EN CORONA DE DIQUE |  | 41d | 2024-09-10 | 2024-10-26 | A8600 SS+1d | 79d | 0d | HH [328 h] | Relleno |
| A8620 |  | COLOCACION Y ACOMODO DE ROCA EN UÑA DE DIQUE |  | 41d | 2024-09-11 | 2024-10-28 | A8610 SS+1d | 79d | 0d | HH [328 h] | Roca |
| A8630 |  | COLOCACION Y ACOMODO DE ROCA EN TALUD DE DIQUE |  | 41d | 2024-09-12 | 2024-10-29 | A8620 SS+1d | 79d | 0d | HH [328 h] | Roca |

| ID | WBS | Activity | Type | Duration | Start | Finish | Predecessors | Total float | Free float | Resources | Filtro |
| --- | --- | --- | --- | --- | --- | --- | --- | --- | --- | --- | --- |
|  | 8 | **DIQUE DE TIERRA COMPACTADA A2-I-01B SIN AFECTACION** |  |  | 2024-08-31 | 2024-09-12 |  |  |  |  |  |
| A8640 |  | ENTREGA DE TERRENO | milestone | 0d | 2024-08-31 | 2024-08-31 | A9020 | 0d |  |  |  |
| A8650 |  | EXCAVACIÓN EN TERRENO NATURAL CON EQUIPO |  | 6d | 2024-09-02 | 2024-09-07 | A8640 SS+1d | 0d |  | HH [48 h] | Excavación |
| A8660 |  | EXCAVACIÓN DE UÑA CON EQUIPO |  | 6d | 2024-09-03 | 2024-09-09 | A8650 SS+1d | 0d |  | HH [48 h] | Excavación |
| A8670 |  | PERFILADO EN ZONA DE CORTE TALUD DE DIQUE |  | 6d | 2024-09-03 | 2024-09-09 | A8650 SS+1d | 0d |  | HH [48 h] |  |
| A8680 |  | PREPARACIÓN DE FUNDACIÓN DE CUERPO DE DIQUE |  | 6d | 2024-09-04 | 2024-09-10 | A8650 SS+1d, A8670 SS+1d, A8660 SS+1d | 0d |  | HH [48 h] |  |
| A8690 |  | CONFORMACIÓN DE CUERPO DE DIQUE CON MATERIAL PROPIO |  | 6d | 2024-09-05 | 2024-09-11 | A8680 SS+1d | 0d |  | HH [48 h] | Relleno |
| A8700 |  | GEOTEXTIL NO TEJIDO 400 G/M2, INC. COLOCACIÓN |  | 6d | 2024-09-05 | 2024-09-11 | A8690 SS | 0d |  | HH [48 h] |  |
| A8710 |  | PERFILADO Y COMPACTACIÓN EN ZONA DE CORTE EN CORONA |  | 6d | 2024-09-05 | 2024-09-11 | A8700 SS | 0d |  | HH [48 h] |  |
| A8720 |  | CONFORMACIÓN DE MATERIAL GRANULAR EN CORONA DE DIQUE |  | 6d | 2024-09-06 | 2024-09-12 | A8710 SS+1d | 0d |  | HH [48 h] | Relleno |
| A8730 |  | COLOCACION Y ACOMODO DE ROCA EN UÑA DE DIQUE |  | 6d | 2024-09-06 | 2024-09-12 | A8720 SS | 0d |  | HH [48 h] | Roca |
| A8740 |  | COLOCACION Y ACOMODO DE ROCA EN TALUD DE DIQUE |  | 6d | 2024-09-06 | 2024-09-12 | A8730 SS | 0d |  | HH [48 h] | Roca |
|  | 15 | **DIQUE DE TIERRA COMPACTADA A2-I-01 POR LIBERAR** |  |  | 2025-01-10 | 2025-02-07 |  |  |  |  |  |
| A8750 |  | ENTREGA DE TERRENO | milestone | 0d | 2025-01-10 | 2025-01-10 | A9300 | 19d | 0d |  |  |
| A8760 |  | EXCAVACIÓN EN TERRENO NATURAL CON EQUIPO |  | 13d | 2025-01-11 | 2025-01-25 | A8750 SS+1d | 19d | 0d | HH [104 h] | Excavación |
| A8770 |  | EXCAVACIÓN DE UÑA CON EQUIPO |  | 13d | 2025-01-13 | 2025-01-27 | A8760 SS+1d | 19d | 0d | HH [104 h] | Excavación |
| A8780 |  | PERFILADO EN ZONA DE CORTE TALUD DE DIQUE |  | 13d | 2025-01-13 | 2025-01-27 | A8760 SS+1d | 20d | 0d | HH [104 h] |  |
| A8790 |  | PREPARACIÓN DE FUNDACIÓN DE CUERPO DE DIQUE |  | 13d | 2025-01-14 | 2025-01-28 | A8760 SS+2d, A8780 SS, A8770 SS+1d | 19d | 0d | HH [104 h] |  |
| A8800 |  | PEDRAPLEN e=60 cm |  | 13d | 2025-01-15 | 2025-01-29 | A8780 FF+2d | 20d | 0d | HH [104 h] | Roca |
| A8810 |  | PEDRAPLEN e=30 cm |  | 13d | 2025-01-15 | 2025-01-29 | A8800 FF | 20d | 1d | HH [104 h] | Roca |
| A8820 |  | CONFORMACIÓN DE CUERPO DE DIQUE CON MATERIAL PROPIO |  | 13d | 2025-01-16 | 2025-01-30 | A8790 SS+2d, A8810 SS | 19d | 0d | HH [104 h] | Relleno |
| A8830 |  | CONFORMACIÓN DE RELLENO NO ESTRUCTURAL CON MATERIAL PROPIO |  | 13d | 2025-01-17 | 2025-01-31 | A8820 SS+1d | 19d | 0d | HH [104 h] | Relleno |
| A8840 |  | GEOTEXTIL NO TEJIDO 400 G/M2, INC. COLOCACIÓN |  | 13d | 2025-01-18 | 2025-02-01 | A8820 SS, A8830 SS+1d | 19d | 0d | HH [104 h] |  |
| A8850 |  | PERFILADO Y COMPACTACIÓN EN ZONA DE CORTE EN CORONA |  | 13d | 2025-01-20 | 2025-02-03 | A8840 SS+1d | 19d | 0d | HH [104 h] |  |
| A8860 |  | CONFORMACIÓN DE MATERIAL GRANULAR EN CORONA DE DIQUE |  | 13d | 2025-01-21 | 2025-02-04 | A8850 SS+1d | 19d | 0d | HH [104 h] | Relleno |
| A8870 |  | COLOCACION Y ACOMODO DE ROCA EN UÑA DE DIQUE |  | 13d | 2025-01-23 | 2025-02-06 | A8860 SS+2d | 19d | 0d | HH [104 h] | Roca |
| A8880 |  | COLOCACION Y ACOMODO DE ROCA EN TALUD DE DIQUE |  | 13d | 2025-01-24 | 2025-02-07 | A8870 SS+1d | 19d |  | HH [104 h] | Roca |

| ID | WBS | Activity | Type | Duration | Start | Finish | Predecessors | Total float | Resources | Filtro |
| --- | --- | --- | --- | --- | --- | --- | --- | --- | --- | --- |
|  | 9 | **DIQUE A2-D-2** |  |  | 2023-12-06 | 2025-02-18 |  |  |  |  |
|  | 1 | **DIQUE DE TIERRA COMPACTADA A2-D-02 SIN AFECTACIÓN** |  |  | 2023-12-06 | 2024-01-30 |  |  |  |  |
| A8170 |  | ENTREGA DE TERRENO | milestone | 0d | 2023-12-06 | 2023-12-06 | A1040 | 0d |  |  |
| A8180 |  | EXCAVACIÓN EN TERRENO NATURAL CON EQUIPO |  | 25d | 2023-12-07 | 2024-01-04 | A8170 SS+1d | 0d | HH [200 h] | Excavación |
| A8190 |  | EXCAVACIÓN DE UÑA CON EQUIPO |  | 25d | 2023-12-08 | 2024-01-05 | A8180 SS+1d | 0d | HH [200 h] | Excavación |
| A8200 |  | PERFILADO EN ZONA DE CORTE TALUD DE DIQUE |  | 25d | 2023-12-08 | 2024-01-05 | A8180 SS+1d | 0d | HH [200 h] |  |
| A8210 |  | PREPARACIÓN DE FUNDACIÓN DE CUERPO DE DIQUE |  | 25d | 2023-12-09 | 2024-01-06 | A8180 SS+1d, A8200 SS+1d, A8190 SS+1d | 0d | HH [200 h] |  |
| A8220 |  | CONFORMACIÓN DE CUERPO DE DIQUE CON MATERIAL PROPIO |  | 25d | 2023-12-28 | 2024-01-25 | A8210 SS+16d | 0d | HH [200 h] | Relleno |
| A8230 |  | GEOTEXTIL NO TEJIDO 400 G/M2, INC. COLOCACIÓN |  | 25d | 2023-12-28 | 2024-01-25 | A8220 SS | 0d | HH [200 h] |  |
| A8240 |  | PERFILADO Y COMPACTACIÓN EN ZONA DE CORTE EN CORONA |  | 25d | 2023-12-29 | 2024-01-26 | A8230 SS+1d | 0d | HH [200 h] |  |
| A8250 |  | CONFORMACIÓN DE MATERIAL GRANULAR EN CORONA DE DIQUE |  | 25d | 2023-12-30 | 2024-01-27 | A8240 SS+1d | 0d | HH [200 h] | Relleno |
| A8260 |  | COLOCACION Y ACOMODO DE ROCA EN UÑA DE DIQUE |  | 25d | 2024-01-01 | 2024-01-29 | A8250 SS+1d | 0d | HH [200 h] | Roca |
| A8270 |  | COLOCACION Y ACOMODO DE ROCA EN TALUD DE DIQUE |  | 25d | 2024-01-02 | 2024-01-30 | A8260 SS+1d | 0d | HH [200 h] | Roca |
|  | 3 | **DIQUE DE TIERRA COMPACTADA A2-D-02 CON AFECTACION** |  |  | 2024-09-13 | 2024-10-07 |  |  |  |  |
| A8280 |  | ENTREGA DE TERRENO | milestone | 0d | 2024-09-13 | 2024-09-13 | A8740 | 0d |  |  |
| A8290 |  | EXCAVACIÓN EN TERRENO NATURAL CON EQUIPO |  | 16d | 2024-09-14 | 2024-10-02 | A8280 SS+1d | 0d | HH [128 h] | Excavación |
| A8300 |  | EXCAVACIÓN DE UÑA CON EQUIPO |  | 16d | 2024-09-16 | 2024-10-03 | A8290 SS+1d | 0d | HH [128 h] | Excavación |
| A8310 |  | PERFILADO EN ZONA DE CORTE TALUD DE DIQUE |  | 16d | 2024-09-16 | 2024-10-03 | A8290 SS+1d | 0d | HH [128 h] |  |
| A8320 |  | PREPARACIÓN DE FUNDACIÓN DE CUERPO DE DIQUE |  | 16d | 2024-09-17 | 2024-10-04 | A8290 SS+1d, A8310 SS+1d, A8300 SS+1d | 0d | HH [128 h] |  |
| A8330 |  | CONFORMACIÓN DE CUERPO DE DIQUE CON MATERIAL PROPIO |  | 16d | 2024-09-18 | 2024-10-05 | A8320 SS+1d | 0d | HH [128 h] | Relleno |
| A8340 |  | GEOTEXTIL NO TEJIDO 400 G/M2, INC. COLOCACIÓN |  | 16d | 2024-09-18 | 2024-10-05 | A8330 SS | 0d | HH [128 h] |  |
| A8350 |  | PERFILADO Y COMPACTACIÓN EN ZONA DE CORTE EN CORONA |  | 16d | 2024-09-18 | 2024-10-05 | A8340 SS | 0d | HH [128 h] |  |
| A8360 |  | CONFORMACIÓN DE MATERIAL GRANULAR EN CORONA DE DIQUE |  | 16d | 2024-09-19 | 2024-10-07 | A8350 SS+1d | 0d | HH [128 h] | Relleno |
| A8370 |  | COLOCACION Y ACOMODO DE ROCA EN UÑA DE DIQUE |  | 16d | 2024-09-19 | 2024-10-07 | A8360 SS | 0d | HH [128 h] | Roca |
| A8380 |  | COLOCACION Y ACOMODO DE ROCA EN TALUD DE DIQUE |  | 16d | 2024-09-19 | 2024-10-07 | A8370 SS | 0d | HH [128 h] | Roca |

| ID | WBS | Activity | Type | Duration | Start | Finish | Predecessors | Total float | Free float | Resources | Filtro |
| --- | --- | --- | --- | --- | --- | --- | --- | --- | --- | --- | --- |
|  | 13 | **DIQUE DE TIERRA COMPACTADA A2-D-02 POR LIBERAR** |  |  | 2025-01-10 | 2025-02-18 |  |  |  |  |  |
| A8390 |  | ENTREGA DE TERRENO | milestone | 0d | 2025-01-10 | 2025-01-10 | A9300 | 10d | 0d |  |  |
| A8400 |  | EXCAVACIÓN EN TERRENO NATURAL CON EQUIPO |  | 18d | 2025-01-11 | 2025-01-31 | A8390 SS+1d | 10d | 0d | HH [144 h] | Excavación |
| A8410 |  | EXCAVACIÓN DE UÑA CON EQUIPO |  | 18d | 2025-01-13 | 2025-02-01 | A8400 SS+1d | 11d | 1d | HH [144 h] | Excavación |
| A8420 |  | PERFILADO EN ZONA DE CORTE TALUD DE DIQUE |  | 18d | 2025-01-14 | 2025-02-03 | A8400 SS+2d | 10d | 0d | HH [144 h] |  |
| A8430 |  | PREPARACIÓN DE FUNDACIÓN DE CUERPO DE DIQUE |  | 18d | 2025-01-15 | 2025-02-04 | A8400 SS+1d, A8420 SS+1d, A8410 SS+1d | 10d | 0d | HH [144 h] |  |
| A8440 |  | CONFORMACIÓN DE CUERPO DE DIQUE CON MATERIAL PROPIO |  | 18d | 2025-01-17 | 2025-02-06 | A8430 SS+2d | 10d | 0d | HH [144 h] | Relleno |
| A8450 |  | GEOTEXTIL NO TEJIDO 400 G/M2, INC. COLOCACIÓN |  | 18d | 2025-01-20 | 2025-02-08 | A8440 SS+2d | 10d | 0d | HH [144 h] |  |
| A8460 |  | PERFILADO Y COMPACTACIÓN EN ZONA DE CORTE EN CORONA |  | 18d | 2025-01-22 | 2025-02-11 | A8450 SS+2d | 10d | 0d | HH [144 h] |  |
| A8470 |  | CONFORMACIÓN DE MATERIAL GRANULAR EN CORONA DE DIQUE |  | 18d | 2025-01-24 | 2025-02-13 | A8460 SS+2d | 10d | 0d | HH [144 h] | Relleno |
| A8480 |  | COLOCACION Y ACOMODO DE ROCA EN UÑA DE DIQUE |  | 18d | 2025-01-27 | 2025-02-15 | A8470 SS+2d | 10d | 0d | HH [144 h] | Roca |
| A8490 |  | COLOCACION Y ACOMODO DE ROCA EN TALUD DE DIQUE |  | 18d | 2025-01-29 | 2025-02-18 | A8480 SS+2d | 10d |  | HH [144 h] | Roca |
|  | 11 | **DIQUE A2-D-1** |  |  | 2024-05-06 | 2025-01-09 |  |  |  |  |  |
|  | 10 | **DIQUE DE TIERRA COMPACTADA A2-D-01 SIN AFECTACION** |  |  | 2024-05-06 | 2024-08-30 |  |  |  |  |  |
| A8890 |  | ENTREGA DE TERRENO | milestone | 0d | 2024-05-06 | 2024-05-06 | A7880 | 0d |  |  |  |
| A8900 |  | EXCAVACIÓN EN TERRENO NATURAL CON EQUIPO |  | 91d | 2024-05-07 | 2024-08-20 | A8890 SS+1d | 0d |  | HH [728 h] | Excavación |
| A8910 |  | PERFILADO EN ZONA DE CORTE TALUD DE DIQUE |  | 91d | 2024-05-07 | 2024-08-20 | A8900 SS | 1d | 0d | HH [728 h] |  |
| A8920 |  | EXCAVACIÓN DE UÑA CON EQUIPO |  | 91d | 2024-05-08 | 2024-08-21 | A8900 SS+1d | 0d |  | HH [728 h] | Excavación |
| A8930 |  | PREPARACIÓN DE FUNDACIÓN DE CUERPO DE DIQUE |  | 91d | 2024-05-09 | 2024-08-22 | A8900 SS+1d, A8910 SS, A8920 SS+1d | 0d |  | HH [728 h] |  |
| A8940 |  | PEDRAPLEN e=60 cm |  | 91d | 2024-05-09 | 2024-08-22 | A8910 FF+2d | 1d | 0d | HH [728 h] | Roca |
| A8950 |  | PEDRAPLEN e=30 cm |  | 91d | 2024-05-09 | 2024-08-22 | A8940 FF | 1d |  | HH [728 h] | Roca |
| A8960 |  | CONFORMACIÓN DE CUERPO DE DIQUE CON MATERIAL PROPIO |  | 91d | 2024-05-10 | 2024-08-23 | A8930 SS+1d, A8950 SS | 0d |  | HH [728 h] | Relleno |
| A8970 |  | CONFORMACIÓN DE RELLENO NO ESTRUCTURAL CON MATERIAL PROPIO |  | 91d | 2024-05-11 | 2024-08-24 | A8960 SS+1d | 0d |  | HH [728 h] | Relleno |
| A8980 |  | GEOTEXTIL NO TEJIDO 400 G/M2, INC. COLOCACIÓN |  | 91d | 2024-05-13 | 2024-08-26 | A8960 SS, A8970 SS+1d | 0d |  | HH [728 h] |  |
| A8990 |  | PERFILADO Y COMPACTACIÓN EN ZONA DE CORTE EN CORONA |  | 91d | 2024-05-14 | 2024-08-27 | A8980 SS+1d | 0d |  | HH [728 h] |  |
| A9000 |  | CONFORMACIÓN DE MATERIAL GRANULAR EN CORONA DE DIQUE |  | 91d | 2024-05-15 | 2024-08-28 | A8990 SS+1d | 0d |  | HH [728 h] | Relleno |
| A9010 |  | COLOCACION Y ACOMODO DE ROCA EN UÑA DE DIQUE |  | 91d | 2024-05-16 | 2024-08-29 | A9000 SS+1d | 0d |  | HH [728 h] | Roca |
| A9020 |  | COLOCACION Y ACOMODO DE ROCA EN TALUD DE DIQUE |  | 91d | 2024-05-17 | 2024-08-30 | A9010 SS+1d | 0d |  | HH [728 h] | Roca |

| ID | WBS | Activity | Type | Duration | Start | Finish | Predecessors | Total float | Free float | Resources | Filtro |
| --- | --- | --- | --- | --- | --- | --- | --- | --- | --- | --- | --- |
|  | 4 | **DIQUE DE TIERRA COMPACTADA A2-D-01 CON AFECTACION** |  |  | 2024-10-08 | 2024-11-14 |  |  |  |  |  |
| A9030 |  | ENTREGA DE TERRENO | milestone | 0d | 2024-10-08 | 2024-10-08 | A8380 | 0d |  |  |  |
| A9040 |  | EXCAVACIÓN EN TERRENO NATURAL CON EQUIPO |  | 18d | 2024-10-09 | 2024-10-29 | A9030 SS+1d | 0d |  | HH [144 h] | Excavación |
| A9050 |  | EXCAVACIÓN DE UÑA CON EQUIPO |  | 18d | 2024-10-10 | 2024-10-30 | A9040 SS+1d | 3d | 0d | HH [144 h] | Excavación |
| A9060 |  | PERFILADO EN ZONA DE CORTE TALUD DE DIQUE |  | 18d | 2024-10-11 | 2024-10-31 | A9040 SS+2d | 0d |  | HH [144 h] |  |
| A9070 |  | PREPARACIÓN DE FUNDACIÓN DE CUERPO DE DIQUE |  | 18d | 2024-10-11 | 2024-10-31 | A9040 SS+2d, A9060 SS, A9050 SS+1d | 3d |  | HH [144 h] |  |
| A9090 |  | PEDRAPLEN e=60 cm |  | 18d | 2024-10-14 | 2024-11-02 | A9060 FF+2d | 0d |  | HH [144 h] | Roca |
| A9080 |  | CONFORMACIÓN DE CUERPO DE DIQUE CON MATERIAL PROPIO |  | 18d | 2024-10-16 | 2024-11-05 | A9070 SS+1d, A9100 SS | 0d |  | HH [144 h] | Relleno |
| A9100 |  | PEDRAPLEN e=30 cm |  | 18d | 2024-10-16 | 2024-11-05 | A9090 FF+2d | 0d |  | HH [144 h] | Roca |
| A9110 |  | CONFORMACIÓN DE RELLENO NO ESTRUCTURAL CON MATERIAL PROPIO |  | 18d | 2024-10-18 | 2024-11-07 | A9080 SS+2d | 0d |  | HH [144 h] | Relleno |
| A9120 |  | GEOTEXTIL NO TEJIDO 400 G/M2, INC. COLOCACIÓN |  | 18d | 2024-10-21 | 2024-11-09 | A9080 SS, A9110 SS+2d | 0d |  | HH [144 h] |  |
| A9130 |  | PERFILADO Y COMPACTACIÓN EN ZONA DE CORTE EN CORONA |  | 18d | 2024-10-22 | 2024-11-11 | A9120 SS+1d | 0d |  | HH [144 h] |  |
| A9140 |  | CONFORMACIÓN DE MATERIAL GRANULAR EN CORONA DE DIQUE |  | 18d | 2024-10-23 | 2024-11-12 | A9130 SS+1d | 0d |  | HH [144 h] | Relleno |
| A9150 |  | COLOCACION Y ACOMODO DE ROCA EN UÑA DE DIQUE |  | 18d | 2024-10-24 | 2024-11-13 | A9140 SS+1d | 0d |  | HH [144 h] | Roca |
| A9160 |  | COLOCACION Y ACOMODO DE ROCA EN TALUD DE DIQUE |  | 18d | 2024-10-25 | 2024-11-14 | A9150 SS+1d | 0d |  | HH [144 h] | Roca |
|  | 5 | **DIQUE DE TIERRA COMPACTADA A2-D-01 POR LIBERAR** |  |  | 2024-11-15 | 2025-01-09 |  |  |  |  |  |
| A9180 |  | ENTREGA DE TERRENO | milestone | 0d | 2024-11-15 | 2024-11-15 | A9160 | 0d |  |  |  |
| A9170 |  | EXCAVACIÓN EN TERRENO NATURAL CON EQUIPO |  | 34d | 2024-11-16 | 2024-12-25 | A9180 SS+1d | 0d |  | HH [272 h] | Excavación |
| A9200 |  | PERFILADO EN ZONA DE CORTE TALUD DE DIQUE |  | 34d | 2024-11-16 | 2024-12-25 | A9170 SS | 0d |  | HH [272 h] |  |
| A9190 |  | EXCAVACIÓN DE UÑA CON EQUIPO |  | 34d | 2024-11-18 | 2024-12-26 | A9170 SS+1d | 0d |  | HH [272 h] | Excavación |
| A9220 |  | PEDRAPLEN e=60 cm |  | 34d | 2024-11-19 | 2024-12-27 | A9200 FF+2d | 0d |  | HH [272 h] | Roca |
| A9210 |  | PREPARACIÓN DE FUNDACIÓN DE CUERPO DE DIQUE |  | 34d | 2024-11-20 | 2024-12-28 | A9170 SS+2d, A9200 SS, A9190 SS+2d | 0d |  | HH [272 h] |  |
| A9230 |  | PEDRAPLEN e=30 cm |  | 34d | 2024-11-21 | 2024-12-30 | A9220 FF+2d | 0d |  | HH [272 h] | Roca |
| A9240 |  | CONFORMACIÓN DE CUERPO DE DIQUE CON MATERIAL PROPIO |  | 34d | 2024-11-21 | 2024-12-30 | A9210 SS+1d, A9230 SS | 0d |  | HH [272 h] | Relleno |
| A9250 |  | CONFORMACIÓN DE RELLENO NO ESTRUCTURAL CON MATERIAL PROPIO |  | 34d | 2024-11-23 | 2025-01-01 | A9240 SS+2d | 0d |  | HH [272 h] | Relleno |
| A9260 |  | GEOTEXTIL NO TEJIDO 400 G/M2, INC. COLOCACIÓN |  | 34d | 2024-11-25 | 2025-01-02 | A9240 SS, A9250 SS+1d | 0d |  | HH [272 h] |  |
| A9270 |  | PERFILADO Y COMPACTACIÓN EN ZONA DE CORTE EN CORONA |  | 34d | 2024-11-26 | 2025-01-03 | A9260 SS+1d | 0d |  | HH [272 h] |  |
| A9280 |  | CONFORMACIÓN DE MATERIAL GRANULAR EN CORONA DE DIQUE |  | 34d | 2024-11-27 | 2025-01-04 | A9270 SS+1d | 0d |  | HH [272 h] | Relleno |
| A9290 |  | COLOCACION Y ACOMODO DE ROCA EN UÑA DE DIQUE |  | 34d | 2024-11-28 | 2025-01-06 | A9280 SS+1d | 0d |  | HH [272 h] | Roca |
| A9300 |  | COLOCACION Y ACOMODO DE ROCA EN TALUD DE DIQUE |  | 36d | 2024-11-29 | 2025-01-09 | A9290 SS+1d | 0d |  | HH [288 h] | Roca |

| ID | WBS | Activity | Duration | Start | Finish | Predecessors | Total float | Free float | Resources |
| --- | --- | --- | --- | --- | --- | --- | --- | --- | --- |
|  | 2 | **OBRAS DE ARTE** |  | 2024-02-27 | 2025-03-01 |  |  |  |  |
|  | 1 | **CAPTACIÓN** |  | 2024-02-27 | 2025-02-28 |  |  |  |  |
| A7240 |  | Construccion de Captaciones | 316d | 2024-02-27 | 2025-02-28 | A7470 | 0d |  | HH [2528 h] |
|  | 3 | **RETORNO A2-OA-RE-I-11-25** |  | 2024-03-09 | 2025-02-28 |  |  |  |  |
| A7250 |  | Construccion de Retorno | 306d | 2024-03-09 | 2025-02-28 | A7240 SS+10d | 0d |  | HH [2448 h] |
|  | 2 | **RETORNOS Q=100 A 1000 l/s** |  | 2024-03-21 | 2025-02-28 |  |  |  |  |
| A7260 |  | Construccion de Retorno | 296d | 2024-03-21 | 2025-02-28 | A7250 SS+10d | 0d |  | HH [2368 h] |
|  | 4 | **REPOSICIÓN DE CANALES** |  | 2024-04-02 | 2025-03-01 |  |  |  |  |
| A7270 |  | Reposicion de Canales | 287d | 2024-04-02 | 2025-03-01 | A7260 SS+10d | 0d |  | HH [2296 h] |
|  | 5 | **TRANSPORTES** |  | 2023-12-07 | 2025-03-01 |  |  |  |  |
|  | 1 | **TRANSPORTES** |  | 2023-12-07 | 2025-03-01 |  |  |  |  |
| A7220 |  | TRANSPORTE DE MATERIAL EXCEDENTE PARA DISTANCIAS <1KM | 387d | 2023-12-07 | 2025-03-01 | A7430 SS | 0d |  | HH [3096 h] |
| A7230 |  | TRANSPORTE DE MATERIAL EXCEDENTE PARA DISTANCIAS >1KM | 387d | 2023-12-07 | 2025-03-01 | A7430 SS | 0d |  | HH [3096 h] |
| A7170 |  | TRANSPORTE DE MATERIAL GRANULAR PARA DISTANCIAS <1KM | 386d | 2023-12-08 | 2025-03-01 | A7450 SS | 0d |  | HH [3088 h] |
| A7190 |  | TRANSPORTE DE MATERIAL GRANULAR PARA DISTANCIAS >1KM | 386d | 2023-12-08 | 2025-03-01 | A7450 SS | 0d |  | HH [3088 h] |
| A7200 |  | TRANSPORTE DE ROCA PARA DISTANCIAS <1KM | 368d | 2023-12-29 | 2025-03-01 | A7510 SS | 0d |  | HH [2944 h] |
| A7210 |  | TRANSPORTE DE ROCA PARA DISTANCIAS >1KM | 368d | 2023-12-29 | 2025-03-01 | A7510 SS | 0d |  | HH [2944 h] |
|  | 3 | **ARQUITECTURA Y PAISAJISMO** |  | 2024-11-16 | 2024-12-30 |  |  |  |  |
|  | 1 | **OBRAS PRELIMINARES** |  | 2024-11-16 | 2024-11-21 |  |  |  |  |
| A3860 |  | Obras Preliminares | 5d | 2024-11-16 | 2024-11-21 | A9170 SS | 53d | 0d | HH [40 h] |
|  | 2 | **MOVIMIENTO DE TIERRAS** |  | 2024-11-16 | 2024-12-26 |  |  |  |  |
| A3890 |  | Movimiento de Tierras | 35d | 2024-11-16 | 2024-12-26 | A3860 SS | 53d | 0d | HH [280 h] |
|  | 3 | **PAVIMENTOS, RECUBRIMIENTOS Y BORDILLOS** |  | 2024-11-28 | 2024-12-30 |  |  |  |  |
| A3930 |  | Pavimientos, Recubrimientos y Bordillos | 28d | 2024-11-28 | 2024-12-30 | A3890 SS+10d | 53d | 0d | HH [224 h] |

| ID | WBS | Activity | Duration | Start | Finish | Predecessors | Total float | Resources | Filtro |
| --- | --- | --- | --- | --- | --- | --- | --- | --- | --- |
|  | 4 | **MOBILIARIOS, BARANDAS Y ESCALERAS** |  | 2024-12-04 | 2024-12-30 |  |  |  |  |
| A4000 |  | Instalacion de Moviliarios, Barandas y escaleras | 23d | 2024-12-04 | 2024-12-30 | A3930 SS+5d | 53d | HH [184 h] |  |
|  | 4 | **PROGRAMA DE CIERRE DE OBRA** |  | 2023-12-05 | 2025-03-01 |  |  |  |  |
| A1770 |  | ACONDICIONAMIENTO DE DEPOSITOS DE MATERIALES EXCEDENTES (DME) | 382d | 2023-12-05 | 2025-02-21 | A1220 SS | 0d | HH [3056 h] | Excavación |
| A1780 |  | RESTAURACIÓN DE ÁREAS DE INSTALACIONES PROVISIONALES | 7d | 2025-02-22 | 2025-03-01 | A1770 | 0d | HH [56 h] |  |
